# The Rostadium Project.mpp

How a schedule from MS Project changed from version to version. A marks actual dates.

## Version 1 (saved 2013-06-12, file Sample Project.mpp)

| ID | WBS | Task | Duration | Start | Finish | Predecessors | Total float |
| --- | --- | --- | --- | --- | --- | --- | --- |
| 1 | 1 | **Planning** | 43d | 2015-03-16 | 2015-05-13 |  | 0d |
| 2 |  | Create architectural plans | 3w | 2015-03-16 | 2015-04-03 |  | 0d |
| 3 |  | Submit plans for approval | 1mo | 2015-04-06 | 2015-05-01 | 2 | 0d |
| 4 |  | Order materials | 8d | 2015-05-04 | 2015-05-13 | 3 | 0d |
| 5 |  | Planning Completed | 0d | 2015-05-13 | 2015-05-13 | 2, 3, 4 | 0d |
| 6 | 2 | **Site Works** | 27d | 2015-05-14 | 2015-06-19 |  | 0d |
| 7 |  | Erect fencing | 3d | 2015-05-14 | 2015-05-18 | 5 | 0d |
| 8 |  | Erect site buildings | 4d | 2015-05-19 | 2015-05-22 | 7 | 0d |
| 9 |  | Clear and level site | 3w | 2015-05-25 | 2015-06-12 | 8 | 0d |
| 10 |  | Prepare drainage infrastructure | 1w | 2015-06-15 | 2015-06-19 | 9 | 0d |
| 11 |  | Prepare cabling infrastructure | 1w | 2015-06-15 | 2015-06-19 | 9 | 0d |
| 12 |  | Site Works Completed | 0d | 2015-06-19 | 2015-06-19 | 7, 8, 9, 10, 11 | 0d |
| 13 | 3 | **Building Construction** | 125d | 2015-06-22 | 2015-12-11 |  | 0d |
| 14 |  | Pour foundations | 4d | 2015-06-22 | 2015-06-25 | 12 | 0d |
| 15 |  | Erect steelwork | 3mo | 2015-06-30 | 2015-09-21 | 14FS+100eh | 0d |
| 16 |  | Erect wall | 2mo | 2015-09-14 | 2015-11-06 | 15FS-1% | 0d |
| 17 |  | Install roofing superstructure | 2w | 2015-11-09 | 2015-11-20 | 16 | 0d |
| 18 |  | Install roof retracting mechanism | 1w | 2015-11-23 | 2015-11-27 | 17 | 0d |
| 19 |  | Erect seating tiers | 3w | 2015-11-23 | 2015-12-11 | 18SS | 0d |
| 20 |  | Building Construction Completed | 0d | 2015-12-11 | 2015-12-11 | 14, 15, 16, 17, 18, 19 | 0d |
| 21 | 4 | **Fit Out** | 33d | 2015-12-14 | 2016-01-27 |  | 0d |
| 22 |  | Fit all windows and doors | 2w | 2015-12-14 | 2015-12-25 | 20 | 23d |
| 23 |  | Install electrical cabling | 1w | 2015-12-14 | 2015-12-18 | 20 | 18d |
| 24 |  | Install electrical fittings and fixtures | 2w | 2015-12-21 | 2016-01-01 | 23 | 18d |
| 25 |  | Install all plumbing | 2w | 2015-12-14 | 2015-12-25 | 20 | 18d |
| 26 |  | Install plumbing fittings and fixtures | 1w | 2015-12-28 | 2016-01-01 | 25 | 18d |
| 27 |  | Lay astro turf | 1w | 2015-12-14 | 2015-12-18 | 20 | 28d |
| 28 |  | Erect handrails and fencing | 2w | 2015-12-14 | 2015-12-25 | 20 | 0d |
| 29 |  | Paint rooms, fixtures, fittings, etc | 1mo | 2015-12-24 | 2016-01-20 | 28FS-2d | 0d |
| 30 |  | Install PA system | 2d | 2015-12-21 | 2015-12-22 | 23 | 21d |
| 31 |  | Install video imaging equipment | 3d | 2015-12-21 | 2015-12-23 | 23 | 20d |
| 32 |  | Fit out control room | 1w | 2016-01-21 | 2016-01-27 | 29, 30, 31 | 0d |
| 33 |  | Fit Out Completed | 0d | 2016-01-27 | 2016-01-27 | 22, 23, 24, 25, 26, 27, 28, 29, 30, 31, 32 | 0d |
| 34 | 5 | **Commissioning** | 14d | 2016-01-28 | 2016-02-16 |  | 0d |
| 35 |  | Test roof mechanism | 1w | 2016-01-28 | 2016-02-03 | 33 | 0d |
| 36 |  | Test PA system | 2d | 2016-01-28 | 2016-01-29 | 33 | 3d |
| 37 |  | Test video imaging equipment | 2d | 2016-01-28 | 2016-01-29 | 33 | 3d |
| 38 |  | Test control room equipment | 1w | 2016-02-04 | 2016-02-10 | 35, 36, 37 | 0d |
| 39 |  | Obtain official occupancy certificates | 1d | 2016-02-11 | 2016-02-11 | 38 | 0d |
| 40 |  | Obtain safety certification | 2d | 2016-02-12 | 2016-02-15 | 39 | 0d |
| 41 |  | Official opening | 1d | 2016-02-16 | 2016-02-16 | 40 | 0d |
| 42 |  | Commissioning Completed | 0d | 2016-02-16 | 2016-02-16 | 35, 36, 37, 38, 39, 40, 41 | 0d |

## Version 2 (saved 2013-07-29, file J1304 Tasks_2.mpp)

Last finish 2016-02-16 → 2016-05-09 (+83d).

Removed: 1 Planning; 5 Planning Completed; 6 Site Works; 12 Site Works Completed; 13 Building Construction; 20 Building Construction Completed; 21 Fit Out; 33 Fit Out Completed; 34 Commissioning; 42 Commissioning Completed

Changed:

| ID | Task | Start | Finish | Duration | Total float | Predecessors | Other |
| --- | --- | --- | --- | --- | --- | --- | --- |
| 1 | Create architectural plans | 2015-03-16 → 2016-05-09 (+420d) | 2015-04-03 → 2016-05-09 (+402d) | 3w → 1d? | 0d → none |  |  |
| 2 | Submit plans for approval | 2015-04-06 → 2016-05-09 (+399d) | 2015-05-01 → 2016-05-09 (+374d) | 1mo → 1d? | 0d → none | 1 → none |  |
| 3 | Order materials | 2015-05-04 → 2016-05-09 (+371d) | 2015-05-13 → 2016-05-09 (+362d) | 8d → 1d? | 0d → none | 2 → none |  |
| 4 | Erect fencing | 2015-05-14 → 2016-05-09 (+361d) | 2015-05-18 → 2016-05-09 (+357d) | 3d → 1d? | 0d → none | Planning Completed → none |  |
| 5 | Erect site buildings | 2015-05-19 → 2016-05-09 (+356d) | 2015-05-22 → 2016-05-09 (+353d) | 4d → 1d? | 0d → none | 4 → none |  |
| 6 | Clear and level site | 2015-05-25 → 2016-05-09 (+350d) | 2015-06-12 → 2016-05-09 (+332d) | 3w → 1d? | 0d → none | 5 → none |  |
| 7 | Prepare drainage infrastructure | 2015-06-15 → 2016-05-09 (+329d) | 2015-06-19 → 2016-05-09 (+325d) | 1w → 1d? | 0d → none | 6 → none |  |
| 8 | Prepare cabling infrastructure | 2015-06-15 → 2016-05-09 (+329d) | 2015-06-19 → 2016-05-09 (+325d) | 1w → 1d? | 0d → none | 6 → none |  |
| 9 | Pour foundations | 2015-06-22 → 2016-05-09 (+322d) | 2015-06-25 → 2016-05-09 (+319d) | 4d → 1d? | 0d → none | Site Works Completed → none |  |
| 10 | Erect steelwork | 2015-06-30 → 2016-05-09 (+314d) | 2015-09-21 → 2016-05-09 (+231d) | 3mo → 1d? | 0d → none | 9FS+100eh → none |  |
| 11 | Erect wall | 2015-09-14 → 2016-05-09 (+238d) | 2015-11-06 → 2016-05-09 (+185d) | 2mo → 1d? | 0d → none | 10FS-1% → none |  |
| 12 | Install roofing superstructure | 2015-11-09 → 2016-05-09 (+182d) | 2015-11-20 → 2016-05-09 (+171d) | 2w → 1d? | 0d → none | 11 → none |  |
| 13 | Install roofing retracting mechanism | 2015-11-23 → 2016-05-09 (+168d) | 2015-11-27 → 2016-05-09 (+164d) | 1w → 1d? | 0d → none | 12 → none | was named Install roof retracting mechanism |
| 14 | Erect seating tiers | 2015-11-23 → 2016-05-09 (+168d) | 2015-12-11 → 2016-05-09 (+150d) | 3w → 1d | 0d → none | 13SS → none |  |
| 15 | Fit all windows and doors | 2015-12-14 → 2016-05-09 (+147d) | 2015-12-25 → 2016-05-09 (+136d) | 2w → 1d | 23d → none | Building Construction Completed → none |  |
| 16 | Install electrical cabling | 2015-12-14 → 2016-05-09 (+147d) | 2015-12-18 → 2016-05-09 (+143d) | 1w → 1d | 18d → none | Building Construction Completed → none |  |
| 17 | Install electrical fittings and fixtures | 2015-12-21 → 2016-05-09 (+140d) | 2016-01-01 → 2016-05-09 (+129d) | 2w → 1d | 18d → none | 16 → none |  |
| 18 | Install all plumbing | 2015-12-14 → 2016-05-09 (+147d) | 2015-12-25 → 2016-05-09 (+136d) | 2w → 1d | 18d → none | Building Construction Completed → none |  |
| 19 | Install plumbing fittings and fixtures | 2015-12-28 → 2016-05-09 (+133d) | 2016-01-01 → 2016-05-09 (+129d) | 1w → 1d | 18d → none | 18 → none |  |
| 20 | Lay astro turf | 2015-12-14 → 2016-05-09 (+147d) | 2015-12-18 → 2016-05-09 (+143d) | 1w → 1d | 28d → none | Building Construction Completed → none |  |
| 21 | Erect handrails and fencing | 2015-12-14 → 2016-05-09 (+147d) | 2015-12-25 → 2016-05-09 (+136d) | 2w → 1d | 0d → none | Building Construction Completed → none |  |
| 22 | Paint rooms, fixtures, fittings, etc | 2015-12-24 → 2016-05-09 (+137d) | 2016-01-20 → 2016-05-09 (+110d) | 1mo → 1d | 0d → none | 21FS-2d → none |  |
| 23 | Install PA system | 2015-12-21 → 2016-05-09 (+140d) | 2015-12-22 → 2016-05-09 (+139d) | 2d → 1d | 21d → none | 16 → none |  |
| 24 | Install video imaging equipment | 2015-12-21 → 2016-05-09 (+140d) | 2015-12-23 → 2016-05-09 (+138d) | 3d → 1d | 20d → none | 16 → none |  |
| 25 | Fit out control room | 2016-01-21 → 2016-05-09 (+109d) | 2016-01-27 → 2016-05-09 (+103d) | 1w → 1d | 0d → none | 22, 23, 24 → none |  |
| 26 | Test roof mechanism | 2016-01-28 → 2016-05-09 (+102d) | 2016-02-03 → 2016-05-09 (+96d) | 1w → 1d | 0d → none | Fit Out Completed → none |  |
| 27 | Test PA system | 2016-01-28 → 2016-05-09 (+102d) | 2016-01-29 → 2016-05-09 (+101d) | 2d → 1d | 3d → none | Fit Out Completed → none |  |
| 28 | Test video imaging equipment | 2016-01-28 → 2016-05-09 (+102d) | 2016-01-29 → 2016-05-09 (+101d) | 2d → 1d | 3d → none | Fit Out Completed → none |  |
| 29 | Test control room equipment | 2016-02-04 → 2016-05-09 (+95d) | 2016-02-10 → 2016-05-09 (+89d) | 1w → 1d | 0d → none | 26, 27, 28 → none |  |
| 30 | Obtain official occupancy certificates | 2016-02-11 → 2016-05-09 (+88d) | 2016-02-11 → 2016-05-09 (+88d) |  | 0d → none | 29 → none |  |
| 31 | Obtain safety certification | 2016-02-12 → 2016-05-09 (+87d) | 2016-02-15 → 2016-05-09 (+84d) | 2d → 1d | 0d → none | 30 → none |  |
| 32 | Official opening | 2016-02-16 → 2016-05-09 (+83d) | 2016-02-16 → 2016-05-09 (+83d) |  | 0d → none | 31 → none |  |

## Version 3 (saved 2013-07-29, file J1304 Tasks_3.mpp)

Last finish stays 2016-05-09.

Added:

| ID | Task | Duration | Start | Finish |
| --- | --- | --- | --- | --- |
| 1 | **Planning** | 1d? | 2016-05-09 | 2016-05-09 |
| 5 | **Site Works** | 1d? | 2016-05-09 | 2016-05-09 |
| 11 | **Building Construction** | 1d? | 2016-05-09 | 2016-05-09 |
| 18 | **Fit Out** | 1d | 2016-05-09 | 2016-05-09 |
| 30 | **Commissioning** | 1d | 2016-05-09 | 2016-05-09 |

## Version 4 (saved 2013-07-29, file J1304 Tasks_4.mpp)

Last finish 2016-05-09 → 2016-07-29 (+81d).

Changed:

| ID | Task | Finish | Duration |
| --- | --- | --- | --- |
| 1 | **Planning** | 2016-05-09 → 2016-06-03 (+25d) | 1d? → 20d |
| 2 | Create architectural plans | 2016-05-09 → 2016-05-27 (+18d) | 1d? → 3w |
| 3 | Submit plans for approval | 2016-05-09 → 2016-06-03 (+25d) | 1d? → 1mo |
| 4 | Order materials | 2016-05-09 → 2016-05-18 (+9d) | 1d? → 8d |
| 5 | **Site Works** | 2016-05-09 → 2016-05-27 (+18d) | 1d? → 15d |
| 6 | Erect fencing | 2016-05-09 → 2016-05-11 (+2d) | 1d? → 3d |
| 7 | Erect site buildings | 2016-05-09 → 2016-05-12 (+3d) | 1d? → 4d |
| 8 | Clear and level site | 2016-05-09 → 2016-05-27 (+18d) | 1d? → 3w |
| 9 | Prepare drainage infrastructure | 2016-05-09 → 2016-05-13 (+4d) | 1d? → 1w |
| 10 | Prepare cabling infrastructure | 2016-05-09 → 2016-05-13 (+4d) | 1d? → 1w |
| 11 | **Building Construction** | 2016-05-09 → 2016-07-29 (+81d) | 1d? → 60d |
| 12 | Pour foundations | 2016-05-09 → 2016-05-12 (+3d) | 1d? → 4d |
| 13 | Erect steelwork | 2016-05-09 → 2016-07-29 (+81d) | 1d? → 3mo |
| 14 | Erect wall | 2016-05-09 → 2016-07-01 (+53d) | 1d? → 2mo |
| 15 | Install roofing superstructure | 2016-05-09 → 2016-05-20 (+11d) | 1d? → 2w |
| 16 | Install roofing retracting mechanism | 2016-05-09 → 2016-05-13 (+4d) | 1d? → 1w |
| 17 | Erect seating tiers | 2016-05-09 → 2016-05-27 (+18d) | 1d → 3w |
| 18 | **Fit Out** | 2016-05-09 → 2016-06-03 (+25d) | 1d → 20d |
| 19 | Fit all windows and doors | 2016-05-09 → 2016-05-20 (+11d) | 1d → 2w |
| 20 | Install electrical cabling | 2016-05-09 → 2016-05-13 (+4d) | 1d → 1w |
| 21 | Install electrical fittings and fixtures | 2016-05-09 → 2016-05-20 (+11d) | 1d → 2w |
| 22 | Install all plumbing | 2016-05-09 → 2016-05-20 (+11d) | 1d → 2w |
| 23 | Install plumbing fittings and fixtures | 2016-05-09 → 2016-05-13 (+4d) | 1d → 1w |
| 24 | Lay astro turf | 2016-05-09 → 2016-05-13 (+4d) | 1d → 1w |
| 25 | Erect handrails and fencing | 2016-05-09 → 2016-05-20 (+11d) | 1d → 2w |
| 26 | Paint rooms, fixtures, fittings, etc | 2016-05-09 → 2016-06-03 (+25d) | 1d → 1mo |
| 27 | Install PA system | 2016-05-09 → 2016-05-10 (+1d) | 1d → 2d |
| 28 | Install video imaging equipment | 2016-05-09 → 2016-05-11 (+2d) | 1d → 3d |
| 29 | Fit out control room | 2016-05-09 → 2016-05-13 (+4d) | 1d → 1w |
| 30 | **Commissioning** | 2016-05-09 → 2016-05-13 (+4d) | 1d → 5d |
| 31 | Test roof mechanism | 2016-05-09 → 2016-05-13 (+4d) | 1d → 1w |
| 32 | Test PA system | 2016-05-09 → 2016-05-10 (+1d) | 1d → 2d |
| 33 | Test video imaging equipment | 2016-05-09 → 2016-05-10 (+1d) | 1d → 2d |
| 34 | Test control room equipment | 2016-05-09 → 2016-05-13 (+4d) | 1d → 1w |
| 36 | Obtain safety certification | 2016-05-09 → 2016-05-10 (+1d) | 1d → 2d |

## Version 5 (saved 2013-07-29, file J1305 Scheduling_1.mpp)

Last finish stays 2016-07-29.

Added:

| ID | Task | Duration | Start | Finish |
| --- | --- | --- | --- | --- |
| 5 | Planning Completed | 0d | 2016-05-09 | 2016-05-09 |
| 12 | Site Works Completed | 0d | 2016-05-09 | 2016-05-09 |
| 20 | Building Construction Completed | 0d | 2016-05-09 | 2016-05-09 |
| 33 | Fit Out Completed | 0d | 2016-05-09 | 2016-05-09 |
| 42 | Commissioning Completed | 0d | 2016-05-09 | 2016-05-09 |

## Version 6 (saved 2013-07-29, file J1305 Scheduling_2.mpp)

Last finish stays 2016-07-29.

Changed:

| ID | Task | Start | Finish | Duration | Predecessors |
| --- | --- | --- | --- | --- | --- |
| 1 | **Planning** |  | 2016-06-03 → 2016-07-07 (+34d) | 20d → 43d |  |
| 3 | Submit plans for approval | 2016-05-09 → 2016-05-30 (+21d) | 2016-06-03 → 2016-06-24 (+21d) |  | none → 2 |
| 4 | Order materials | 2016-05-09 → 2016-06-27 (+49d) | 2016-05-18 → 2016-07-06 (+49d) |  | none → 3 |
| 5 | Planning Completed | 2016-05-09 → 2016-07-07 (+59d) | 2016-05-09 → 2016-07-07 (+59d) |  | none → 4 |

## Version 7 (saved 2013-07-29, file J1305 Scheduling_3.mpp)

Last finish stays 2016-07-29.

Changed:

| ID | Task | Predecessors |
| --- | --- | --- |
| 5 | Planning Completed | 4 → 4, 2, 3 |

## Version 8 (saved 2013-07-29, file J1305 Scheduling_4.mpp)

Last finish stays 2016-07-29.

Changed:

| ID | Task | Start | Finish | Predecessors |
| --- | --- | --- | --- | --- |
| 6 | **Site Works** | 2016-05-09 → 2016-07-07 (+59d) | 2016-05-27 → 2016-07-27 (+61d) |  |
| 7 | Erect fencing | 2016-05-09 → 2016-07-07 (+59d) | 2016-05-11 → 2016-07-11 (+61d) | none → 5 |
| 8 | Erect site buildings | 2016-05-09 → 2016-07-07 (+59d) | 2016-05-12 → 2016-07-12 (+61d) |  |
| 9 | Clear and level site | 2016-05-09 → 2016-07-07 (+59d) | 2016-05-27 → 2016-07-27 (+61d) |  |
| 10 | Prepare drainage infrastructure | 2016-05-09 → 2016-07-07 (+59d) | 2016-05-13 → 2016-07-13 (+61d) |  |
| 11 | Prepare cabling infrastructure | 2016-05-09 → 2016-07-07 (+59d) | 2016-05-13 → 2016-07-13 (+61d) |  |
| 12 | Site Works Completed | 2016-05-09 → 2016-07-07 (+59d) | 2016-05-09 → 2016-07-07 (+59d) |  |

## Version 9 (saved 2013-07-29, file J1305 Scheduling_5.mpp)

Last finish 2016-07-29 → 2017-05-23 (+298d).

Changed:

| ID | Task | Start | Finish | Duration | Predecessors |
| --- | --- | --- | --- | --- | --- |
| 6 | **Site Works** |  | 2016-07-27 → 2016-08-15 (+19d) | 15d → 27d |  |
| 8 | Erect site buildings | 2016-07-07 → 2016-07-12 (+5d) | 2016-07-12 → 2016-07-15 (+3d) |  | none → 7 |
| 9 | Clear and level site | 2016-07-07 → 2016-07-18 (+11d) | 2016-07-27 → 2016-08-05 (+9d) |  | none → 8 |
| 10 | Prepare drainage infrastructure | 2016-07-07 → 2016-08-08 (+32d) | 2016-07-13 → 2016-08-12 (+30d) |  | none → 9 |
| 11 | Prepare cabling infrastructure | 2016-07-07 → 2016-08-08 (+32d) | 2016-07-13 → 2016-08-12 (+30d) |  | none → 9 |
| 12 | Site Works Completed | 2016-07-07 → 2016-08-15 (+39d) | 2016-07-07 → 2016-08-15 (+39d) |  | none → 7, 8, 9, 10, 11 |
| 13 | **Building Construction** | 2016-05-09 → 2016-08-15 (+98d) | 2016-07-29 → 2017-03-08 (+222d) | 60d → 134d |  |
| 14 | Pour foundations | 2016-05-09 → 2016-08-15 (+98d) | 2016-05-12 → 2016-08-18 (+98d) |  | none → 12 |
| 15 | Erect steelwork | 2016-05-09 → 2016-08-19 (+102d) | 2016-07-29 → 2016-11-10 (+104d) |  | none → 14 |
| 16 | Erect wall | 2016-05-09 → 2016-11-11 (+186d) | 2016-07-01 → 2017-01-24 (+207d) |  | none → 15 |
| 17 | Install roofing superstructure | 2016-05-09 → 2017-01-25 (+261d) | 2016-05-20 → 2017-02-07 (+263d) |  | none → 16 |
| 18 | Install roofing retracting mechanism | 2016-05-09 → 2017-02-08 (+275d) | 2016-05-13 → 2017-02-14 (+277d) |  | none → 17 |
| 19 | Erect seating tiers | 2016-05-09 → 2017-02-15 (+282d) | 2016-05-27 → 2017-03-07 (+284d) |  | none → 18 |
| 20 | Building Construction Completed | 2016-05-09 → 2017-03-08 (+303d) | 2016-05-09 → 2017-03-08 (+303d) |  | none → 14, 15, 16, 17, 18, 19 |
| 21 | **Fit Out** | 2016-05-09 → 2017-03-08 (+303d) | 2016-06-03 → 2017-05-03 (+334d) | 20d → 40d |  |
| 22 | Fit all windows and doors | 2016-05-09 → 2017-03-08 (+303d) | 2016-05-20 → 2017-03-21 (+305d) |  | none → 20 |
| 23 | Install electrical cabling | 2016-05-09 → 2017-03-08 (+303d) | 2016-05-13 → 2017-03-14 (+305d) |  | none → 20 |
| 24 | Install electrical fittings and fixtures | 2016-05-09 → 2017-03-15 (+310d) | 2016-05-20 → 2017-03-28 (+312d) |  | none → 23 |
| 25 | Install all plumbing | 2016-05-09 → 2017-03-08 (+303d) | 2016-05-20 → 2017-03-21 (+305d) |  | none → 20 |
| 26 | Install plumbing fittings and fixtures | 2016-05-09 → 2017-03-22 (+317d) | 2016-05-13 → 2017-03-28 (+319d) |  | none → 25 |
| 27 | Lay astro turf | 2016-05-09 → 2017-03-08 (+303d) | 2016-05-13 → 2017-03-14 (+305d) |  | none → 20 |
| 28 | Erect handrails and fencing | 2016-05-09 → 2017-03-15 (+310d) | 2016-05-20 → 2017-03-28 (+312d) |  | none → 27 |
| 29 | Paint rooms, fixtures, fittings, etc | 2016-05-09 → 2017-03-29 (+324d) | 2016-06-03 → 2017-04-25 (+326d) |  | none → 28 |
| 30 | Install PA system | 2016-05-09 → 2017-03-15 (+310d) | 2016-05-10 → 2017-03-16 (+310d) |  | none → 23 |
| 31 | Install video imaging equipment | 2016-05-09 → 2017-03-15 (+310d) | 2016-05-11 → 2017-03-17 (+310d) |  | none → 23 |
| 32 | Fit out control room | 2016-05-09 → 2017-04-26 (+352d) | 2016-05-13 → 2017-05-02 (+354d) |  | none → 29, 30, 31 |
| 33 | Fit Out Completed | 2016-05-09 → 2017-05-03 (+359d) | 2016-05-09 → 2017-05-03 (+359d) |  | none → 22, 23, 24, 25, 26, 27, 28, 29, 30, 31, 32 |
| 34 | **Commissioning** | 2016-05-09 → 2017-05-03 (+359d) | 2016-05-13 → 2017-05-23 (+375d) | 5d → 14d |  |
| 35 | Test roof mechanism | 2016-05-09 → 2017-05-03 (+359d) | 2016-05-13 → 2017-05-09 (+361d) |  | none → 33 |
| 36 | Test PA system | 2016-05-09 → 2017-05-03 (+359d) | 2016-05-10 → 2017-05-04 (+359d) |  | none → 33 |
| 37 | Test video imaging equipment | 2016-05-09 → 2017-05-03 (+359d) | 2016-05-10 → 2017-05-04 (+359d) |  | none → 33 |
| 38 | Test control room equipment | 2016-05-09 → 2017-05-10 (+366d) | 2016-05-13 → 2017-05-16 (+368d) |  | none → 35, 36, 37 |
| 39 | Obtain official occupancy certificates | 2016-05-09 → 2017-05-17 (+373d) | 2016-05-09 → 2017-05-17 (+373d) |  | none → 38 |
| 40 | Obtain safety certification | 2016-05-09 → 2017-05-18 (+374d) | 2016-05-10 → 2017-05-19 (+374d) |  | none → 39 |
| 41 | Official opening | 2016-05-09 → 2017-05-22 (+378d) | 2016-05-09 → 2017-05-22 (+378d) |  | none → 40 |
| 42 | Commissioning Completed | 2016-05-09 → 2017-05-23 (+379d) | 2016-05-09 → 2017-05-23 (+379d) |  | none → 35, 36, 37, 38, 39, 40, 41 |

## Version 10 (saved 2013-07-29, file J1305 Scheduling_6.mpp)

Last finish stays 2017-05-23.

Changed:

| ID | Task | Start | Finish | Duration | Predecessors |
| --- | --- | --- | --- | --- | --- |
| 13 | **Building Construction** |  | 2017-03-08 → 2017-03-01 (-7d) | 134d → 129d |  |
| 19 | Erect seating tiers | 2017-02-15 → 2017-02-08 (-7d) | 2017-03-07 → 2017-02-21 (-14d) | 3w → 2w | 18 → 18SS |
| 20 | Building Construction Completed | 2017-03-08 → 2017-03-01 (-7d) | 2017-03-08 → 2017-03-01 (-7d) |  |  |
| 28 | Erect handrails and fencing |  |  |  | 27 → 20 |

## Version 11 (saved 2013-07-29, file J1305 Scheduling_7.mpp)

Last finish 2017-05-23 → 2017-05-01 (-22d).

Changed:

| ID | Task | Start | Finish | Duration | Total float |
| --- | --- | --- | --- | --- | --- |
| 1 | **Planning** |  | 2016-07-07 → 2016-07-06 (-1d) |  |  |
| 5 | Planning Completed | 2016-07-07 → 2016-07-06 (-1d) | 2016-07-07 → 2016-07-06 (-1d) |  | none → 0d |
| 6 | **Site Works** |  | 2016-08-15 → 2016-08-12 (-3d) |  |  |
| 12 | Site Works Completed | 2016-08-15 → 2016-08-12 (-3d) | 2016-08-15 → 2016-08-12 (-3d) |  | none → 0d |
| 13 | **Building Construction** |  | 2017-03-01 → 2017-02-21 (-8d) | 129d → 124d |  |
| 20 | Building Construction Completed | 2017-03-01 → 2017-02-21 (-8d) | 2017-03-01 → 2017-02-21 (-8d) |  | none → 0d |
| 21 | **Fit Out** | 2017-03-08 → 2017-02-22 (-14d) | 2017-05-03 → 2017-04-11 (-22d) | 40d → 35d |  |
| 22 | Fit all windows and doors | 2017-03-08 → 2017-02-22 (-14d) | 2017-03-21 → 2017-03-07 (-14d) |  | none → 25d |
| 23 | Install electrical cabling | 2017-03-08 → 2017-02-22 (-14d) | 2017-03-14 → 2017-02-28 (-14d) |  | none → 20d |
| 24 | Install electrical fittings and fixtures | 2017-03-15 → 2017-03-01 (-14d) | 2017-03-28 → 2017-03-14 (-14d) |  | none → 20d |
| 25 | Install all plumbing | 2017-03-08 → 2017-02-22 (-14d) | 2017-03-21 → 2017-03-07 (-14d) |  | none → 20d |
| 26 | Install plumbing fittings and fixtures | 2017-03-22 → 2017-03-08 (-14d) | 2017-03-28 → 2017-03-14 (-14d) |  | none → 20d |
| 27 | Lay astro turf | 2017-03-08 → 2017-02-22 (-14d) | 2017-03-14 → 2017-02-28 (-14d) |  | none → 30d |
| 28 | Erect handrails and fencing | 2017-03-15 → 2017-02-22 (-21d) | 2017-03-28 → 2017-03-07 (-21d) |  | none → 0d |
| 29 | Paint rooms, fixtures, fittings, etc | 2017-03-29 → 2017-03-08 (-21d) | 2017-04-25 → 2017-04-04 (-21d) |  | none → 0d |
| 30 | Install PA system | 2017-03-15 → 2017-03-01 (-14d) | 2017-03-16 → 2017-03-02 (-14d) |  | none → 23d |
| 31 | Install video imaging equipment | 2017-03-15 → 2017-03-01 (-14d) | 2017-03-17 → 2017-03-03 (-14d) |  | none → 22d |
| 32 | Fit out control room | 2017-04-26 → 2017-04-05 (-21d) | 2017-05-02 → 2017-04-11 (-21d) |  | none → 0d |
| 33 | Fit Out Completed | 2017-05-03 → 2017-04-11 (-22d) | 2017-05-03 → 2017-04-11 (-22d) |  | none → 0d |
| 34 | **Commissioning** | 2017-05-03 → 2017-04-12 (-21d) | 2017-05-23 → 2017-05-01 (-22d) |  |  |
| 35 | Test roof mechanism | 2017-05-03 → 2017-04-12 (-21d) | 2017-05-09 → 2017-04-18 (-21d) |  | none → 0d |
| 36 | Test PA system | 2017-05-03 → 2017-04-12 (-21d) | 2017-05-04 → 2017-04-13 (-21d) |  | none → 3d |
| 37 | Test video imaging equipment | 2017-05-03 → 2017-04-12 (-21d) | 2017-05-04 → 2017-04-13 (-21d) |  | none → 3d |
| 38 | Test control room equipment | 2017-05-10 → 2017-04-19 (-21d) | 2017-05-16 → 2017-04-25 (-21d) |  | none → 0d |
| 39 | Obtain official occupancy certificates | 2017-05-17 → 2017-04-26 (-21d) | 2017-05-17 → 2017-04-26 (-21d) |  | none → 0d |
| 40 | Obtain safety certification | 2017-05-18 → 2017-04-27 (-21d) | 2017-05-19 → 2017-04-28 (-21d) |  | none → 0d |
| 41 | Official opening | 2017-05-22 → 2017-05-01 (-21d) | 2017-05-22 → 2017-05-01 (-21d) |  | none → 0d |
| 42 | Commissioning Completed | 2017-05-23 → 2017-05-01 (-22d) | 2017-05-23 → 2017-05-01 (-22d) |  | none → 0d |

## Version 12 (saved 2013-07-29, file J1305 Scheduling_10.mpp)

Last finish 2017-05-01 → 2017-05-03 (+2d).

Changed:

| ID | Task | Start | Finish | Duration | Predecessors |
| --- | --- | --- | --- | --- | --- |
| 13 | **Building Construction** |  | 2017-02-21 → 2017-02-23 (+2d) | 124d → 126d |  |
| 15 | Erect steelwork | 2016-08-19 → 2016-08-23 (+4d) | 2016-11-10 → 2016-11-14 (+4d) |  | 14 → 14FS+100eh |
| 16 | Erect wall | 2016-11-11 → 2016-11-15 (+4d) | 2017-01-24 → 2017-01-26 (+2d) |  |  |
| 17 | Install roofing superstructure | 2017-01-25 → 2017-01-27 (+2d) | 2017-02-07 → 2017-02-09 (+2d) |  |  |
| 18 | Install roofing retracting mechanism | 2017-02-08 → 2017-02-10 (+2d) | 2017-02-14 → 2017-02-16 (+2d) |  |  |
| 19 | Erect seating tiers | 2017-02-08 → 2017-02-10 (+2d) | 2017-02-21 → 2017-02-23 (+2d) |  |  |
| 20 | Building Construction Completed | 2017-02-21 → 2017-02-23 (+2d) | 2017-02-21 → 2017-02-23 (+2d) |  |  |
| 21 | **Fit Out** | 2017-02-22 → 2017-02-24 (+2d) | 2017-04-11 → 2017-04-13 (+2d) |  |  |
| 22 | Fit all windows and doors | 2017-02-22 → 2017-02-24 (+2d) | 2017-03-07 → 2017-03-09 (+2d) |  |  |
| 23 | Install electrical cabling | 2017-02-22 → 2017-02-24 (+2d) | 2017-02-28 → 2017-03-02 (+2d) |  |  |
| 24 | Install electrical fittings and fixtures | 2017-03-01 → 2017-03-03 (+2d) | 2017-03-14 → 2017-03-16 (+2d) |  |  |
| 25 | Install all plumbing | 2017-02-22 → 2017-02-24 (+2d) | 2017-03-07 → 2017-03-09 (+2d) |  |  |
| 26 | Install plumbing fittings and fixtures | 2017-03-08 → 2017-03-10 (+2d) | 2017-03-14 → 2017-03-16 (+2d) |  |  |
| 27 | Lay astro turf | 2017-02-22 → 2017-02-24 (+2d) | 2017-02-28 → 2017-03-02 (+2d) |  |  |
| 28 | Erect handrails and fencing | 2017-02-22 → 2017-02-24 (+2d) | 2017-03-07 → 2017-03-09 (+2d) |  |  |
| 29 | Paint rooms, fixtures, fittings, etc | 2017-03-08 → 2017-03-10 (+2d) | 2017-04-04 → 2017-04-06 (+2d) |  |  |
| 30 | Install PA system | 2017-03-01 → 2017-03-03 (+2d) | 2017-03-02 → 2017-03-06 (+4d) |  |  |
| 31 | Install video imaging equipment | 2017-03-01 → 2017-03-03 (+2d) | 2017-03-03 → 2017-03-07 (+4d) |  |  |
| 32 | Fit out control room | 2017-04-05 → 2017-04-07 (+2d) | 2017-04-11 → 2017-04-13 (+2d) |  |  |
| 33 | Fit Out Completed | 2017-04-11 → 2017-04-13 (+2d) | 2017-04-11 → 2017-04-13 (+2d) |  |  |
| 34 | **Commissioning** | 2017-04-12 → 2017-04-14 (+2d) | 2017-05-01 → 2017-05-03 (+2d) |  |  |
| 35 | Test roof mechanism | 2017-04-12 → 2017-04-14 (+2d) | 2017-04-18 → 2017-04-20 (+2d) |  |  |
| 36 | Test PA system | 2017-04-12 → 2017-04-14 (+2d) | 2017-04-13 → 2017-04-17 (+4d) |  |  |
| 37 | Test video imaging equipment | 2017-04-12 → 2017-04-14 (+2d) | 2017-04-13 → 2017-04-17 (+4d) |  |  |
| 38 | Test control room equipment | 2017-04-19 → 2017-04-21 (+2d) | 2017-04-25 → 2017-04-27 (+2d) |  |  |
| 39 | Obtain official occupancy certificates | 2017-04-26 → 2017-04-28 (+2d) | 2017-04-26 → 2017-04-28 (+2d) |  |  |
| 40 | Obtain safety certification | 2017-04-27 → 2017-05-01 (+4d) | 2017-04-28 → 2017-05-02 (+4d) |  |  |
| 41 | Official opening | 2017-05-01 → 2017-05-03 (+2d) | 2017-05-01 → 2017-05-03 (+2d) |  |  |
| 42 | Commissioning Completed | 2017-05-01 → 2017-05-03 (+2d) | 2017-05-01 → 2017-05-03 (+2d) |  |  |

## Version 13 (saved 2013-07-29, file J1306 Resources_1.mpp)

Last finish 2017-05-03 → 2017-04-21 (-12d).

Changed:

| ID | Task | Start | Finish | Duration | Total float | Predecessors |
| --- | --- | --- | --- | --- | --- | --- |
| 13 | **Building Construction** |  | 2017-02-23 → 2017-02-15 (-8d) | 126d → 120d |  |  |
| 16 | Erect wall | 2016-11-15 → 2016-11-07 (-8d) | 2017-01-26 → 2017-01-18 (-8d) |  |  | 15 → 15FS-1% |
| 17 | Install roofing superstructure | 2017-01-27 → 2017-01-19 (-8d) | 2017-02-09 → 2017-02-01 (-8d) |  |  |  |
| 18 | Install roofing retracting mechanism | 2017-02-10 → 2017-02-02 (-8d) | 2017-02-16 → 2017-02-08 (-8d) |  |  |  |
| 19 | Erect seating tiers | 2017-02-10 → 2017-02-02 (-8d) | 2017-02-23 → 2017-02-15 (-8d) |  |  |  |
| 20 | Building Construction Completed | 2017-02-23 → 2017-02-15 (-8d) | 2017-02-23 → 2017-02-15 (-8d) |  |  |  |
| 21 | **Fit Out** | 2017-02-24 → 2017-02-16 (-8d) | 2017-04-13 → 2017-04-03 (-10d) | 35d → 33d |  |  |
| 22 | Fit all windows and doors | 2017-02-24 → 2017-02-16 (-8d) | 2017-03-09 → 2017-03-01 (-8d) |  | 25d → 23d |  |
| 23 | Install electrical cabling | 2017-02-24 → 2017-02-16 (-8d) | 2017-03-02 → 2017-02-22 (-8d) |  | 20d → 18d |  |
| 24 | Install electrical fittings and fixtures | 2017-03-03 → 2017-02-23 (-8d) | 2017-03-16 → 2017-03-08 (-8d) |  | 20d → 18d |  |
| 25 | Install all plumbing | 2017-02-24 → 2017-02-16 (-8d) | 2017-03-09 → 2017-03-01 (-8d) |  | 20d → 18d |  |
| 26 | Install plumbing fittings and fixtures | 2017-03-10 → 2017-03-02 (-8d) | 2017-03-16 → 2017-03-08 (-8d) |  | 20d → 18d |  |
| 27 | Lay astro turf | 2017-02-24 → 2017-02-16 (-8d) | 2017-03-02 → 2017-02-22 (-8d) |  | 30d → 28d |  |
| 28 | Erect handrails and fencing | 2017-02-24 → 2017-02-16 (-8d) | 2017-03-09 → 2017-03-01 (-8d) |  |  |  |
| 29 | Paint rooms, fixtures, fittings, etc | 2017-03-10 → 2017-02-28 (-10d) | 2017-04-06 → 2017-03-27 (-10d) |  |  | 28 → 28FS-2d |
| 30 | Install PA system | 2017-03-03 → 2017-02-23 (-8d) | 2017-03-06 → 2017-02-24 (-10d) |  | 23d → 21d |  |
| 31 | Install video imaging equipment | 2017-03-03 → 2017-02-23 (-8d) | 2017-03-07 → 2017-02-27 (-8d) |  | 22d → 20d |  |
| 32 | Fit out control room | 2017-04-07 → 2017-03-28 (-10d) | 2017-04-13 → 2017-04-03 (-10d) |  |  |  |
| 33 | Fit Out Completed | 2017-04-13 → 2017-04-03 (-10d) | 2017-04-13 → 2017-04-03 (-10d) |  |  |  |
| 34 | **Commissioning** | 2017-04-14 → 2017-04-04 (-10d) | 2017-05-03 → 2017-04-21 (-12d) |  |  |  |
| 35 | Test roof mechanism | 2017-04-14 → 2017-04-04 (-10d) | 2017-04-20 → 2017-04-10 (-10d) |  |  |  |
| 36 | Test PA system | 2017-04-14 → 2017-04-04 (-10d) | 2017-04-17 → 2017-04-05 (-12d) |  |  |  |
| 37 | Test video imaging equipment | 2017-04-14 → 2017-04-04 (-10d) | 2017-04-17 → 2017-04-05 (-12d) |  |  |  |
| 38 | Test control room equipment | 2017-04-21 → 2017-04-11 (-10d) | 2017-04-27 → 2017-04-17 (-10d) |  |  |  |
| 39 | Obtain official occupancy certificates | 2017-04-28 → 2017-04-18 (-10d) | 2017-04-28 → 2017-04-18 (-10d) |  |  |  |
| 40 | Obtain safety certification | 2017-05-01 → 2017-04-19 (-12d) | 2017-05-02 → 2017-04-20 (-12d) |  |  |  |
| 41 | Official opening | 2017-05-03 → 2017-04-21 (-12d) | 2017-05-03 → 2017-04-21 (-12d) |  |  |  |
| 42 | Commissioning Completed | 2017-05-03 → 2017-04-21 (-12d) | 2017-05-03 → 2017-04-21 (-12d) |  |  |  |

## Version 14 (saved 2013-08-02, file J1308 Assignment_2.mpp)

Last finish stays 2017-04-21.

Changed:

| ID | Task | Other |
| --- | --- | --- |
| 2 | Create architectural plans | resources none → Architect; Draftsperson [200%] |

## Version 15 (saved 2013-08-02, file J1308 Assignment_3.mpp)

Last finish stays 2017-04-21.

Changed:

| ID | Task | Other |
| --- | --- | --- |
| 2 | Create architectural plans | resources Architect; Draftsperson [200%] → Architect; Draftsperson [200%]; Building Clerk [25%] |

## Version 16 (saved 2013-08-02, file J1308 Assignment_4.mpp)

Last finish stays 2017-04-21.

Changed:

| ID | Task | Other |
| --- | --- | --- |
| 3 | Submit plans for approval | resources none → Architect |

## Version 17 (saved 2013-08-02, file J1308 Assignment_7.mpp)

Last finish stays 2017-04-21.

Changed:

| ID | Task | Other |
| --- | --- | --- |
| 4 | Order materials | resources none → Draftsperson; Building Clerk |

## Version 18 (saved 2013-08-02, file J1308 Assignment_8.mpp)

Last finish stays 2017-04-21.

Changed:

| ID | Task | Other |
| --- | --- | --- |
| 7 | Erect fencing | resources none → No Barrier Fencing |

## Version 19 (saved 2013-08-02, file J1308 Assignment_9.mpp)

Last finish stays 2017-04-21.

Changed:

| ID | Task | Other |
| --- | --- | --- |
| 8 | Erect site buildings | resources none → Supervisor; Carpenter [400%]; Labourer [800%] |

## Version 20 (saved 2013-08-02, file J1308 Assignment_10.mpp)

Last finish stays 2017-04-21.

Changed:

| ID | Task | Other |
| --- | --- | --- |
| 9 | Clear and level site | resources none → Driver [200%]; Grader [200%]; Supervisor |

## Version 21 (saved 2013-08-02, file J1309 Levelling_1.mpp)

Last finish stays 2017-04-21.

Changed:

| ID | Task | Other |
| --- | --- | --- |
| 10 | Prepare drainage infrastructure | resources none → Supervisor [50%]; Plumber [200%] |
| 11 | Prepare cabling infrastructure | resources none → Supervisor [50%]; Electrician [300%] |
| 14 | Pour foundations | resources none → Rock Solid Concrete |
| 15 | Erect steelwork | resources none → Supervisor [50%]; Rigger [600%]; Boilermaker [600%]; Welder [500%]; Labourer [600%]; Driver [200%]; High Jib Crane; Utility |
| 16 | Erect wall | resources none → Supervisor [50%]; Carpenter [700%]; Labourer [400%]; Driver; Grader; Air Compressor; Electrician [75%]; Plumber [25%] |
| 17 | Install roofing superstructure | resources none → Supervisor [50%]; Rigger [500%]; Boilermaker [500%]; Welder [300%]; Labourer [500%]; Driver [200%]; High Jib Crane; Utility; Air Compressor; Plumber [50%] |
| 18 | Install roofing retracting mechanism | resources none → Supervisor [50%]; Welder; Boilermaker [200%]; Rigger [200%]; Electrician [200%]; Driver; High Jib Crane |
| 19 | Erect seating tiers | resources none → Supervisor [50%]; Carpenter [800%]; Welder [200%]; Boilermaker [200%]; Labourer [500%]; Driver; Utility; Air Compressor |
| 22 | Fit all windows and doors | resources none → Carpenter [500%]; Labourer [200%] |
| 23 | Install electrical cabling | resources none → Electrician [300%]; Labourer [200%] |
| 24 | Install electrical fittings and fixtures | resources none → Electrician [300%] |
| 25 | Install all plumbing | resources none → Plumber [200%]; Labourer [200%] |
| 26 | Install plumbing fittings and fixtures | resources none → Plumber [200%] |
| 27 | Lay astro turf | resources none → Pure Grass Turf |
| 28 | Erect handrails and fencing | resources none → Welder [400%]; Boilermaker [200%] |
| 29 | Paint rooms, fixtures, fittings, etc | resources none → Painter [500%] |
| 30 | Install PA system | resources none → Listen Ear Audio |
| 31 | Install video imaging equipment | resources none → In Focus Video |
| 32 | Fit out control room | resources none → Electrician [200%]; Listen Ear Audio; In Focus Video |
| 35 | Test roof mechanism | resources none → Supervisor; Electrician [200%]; Rigger |
| 36 | Test PA system | resources none → Listen Ear Audio |
| 37 | Test video imaging equipment | resources none → In Focus Video |
| 38 | Test control room equipment | resources none → Supervisor; Listen Ear Audio [20%]; In Focus Video [20%]; Architect; Electrician [200%] |
| 39 | Obtain official occupancy certificates | resources none → Architect; Building Clerk; Supervisor |

## Version 22 (saved 2013-08-07, file J1309 Levelling_4.mpp)

Last finish stays 2017-04-21.

Changed:

| ID | Task | Other |
| --- | --- | --- |
| 2 | Create architectural plans | resources Architect; Draftsperson [200%]; Building Clerk [25%] → Architect; Draftsperson; Building Clerk [25%] |

## Version 23 (saved 2013-08-07, file J1309 Levelling_5.mpp)

Last finish stays 2017-04-21.

Changed:

| ID | Task | Other |
| --- | --- | --- |
| 15 | Erect steelwork | resources Supervisor [50%]; Rigger [600%]; Boilermaker [600%]; Welder [500%]; Labourer [600%]; Driver [200%]; High Jib Crane; Utility → Supervisor [50%]; Rigger [500%]; Boilermaker [600%]; Welder [500%]; Labourer [600%]; Driver [200%]; High Jib Crane; Utility |

## Version 24 (saved 2013-08-07, file J1309 Levelling_6.mpp)

Last finish stays 2017-04-21.

Changed:

| ID | Task | Other |
| --- | --- | --- |
| 16 | Erect wall | resources Supervisor [50%]; Carpenter [700%]; Labourer [400%]; Driver; Grader; Air Compressor; Electrician [75%]; Plumber [25%] → Supervisor [50%]; Carpenter [600%]; Labourer [400%]; Driver; Grader; Air Compressor; Electrician [75%]; Plumber [25%]; On The Hammer |

## Version 25 (saved 2013-08-07, file J1309 Levelling_7.mpp)

Last finish 2017-04-21 → 2017-04-28 (+7d).

Changed:

| ID | Task | Start | Finish | Duration | Other |
| --- | --- | --- | --- | --- | --- |
| 13 | **Building Construction** |  | 2017-02-15 → 2017-02-22 (+7d) | 120d → 125d |  |
| 19 | Erect seating tiers |  | 2017-02-15 → 2017-02-22 (+7d) | 2w → 3w | resources Supervisor [50%]; Carpenter [800%]; Welder [200%]; Boilermaker [200%]; Labourer [500%]; Driver; Utility; Air Compressor → Supervisor [50%]; Carpenter [600%]; Welder [200%]; Boilermaker [200%]; Labourer [700%]; Driver; Utility; Air Compressor |
| 20 | Building Construction Completed | 2017-02-15 → 2017-02-22 (+7d) | 2017-02-15 → 2017-02-22 (+7d) |  |  |
| 21 | **Fit Out** | 2017-02-16 → 2017-02-23 (+7d) | 2017-04-03 → 2017-04-10 (+7d) |  |  |
| 22 | Fit all windows and doors | 2017-02-16 → 2017-02-23 (+7d) | 2017-03-01 → 2017-03-08 (+7d) |  |  |
| 23 | Install electrical cabling | 2017-02-16 → 2017-02-23 (+7d) | 2017-02-22 → 2017-03-01 (+7d) |  |  |
| 24 | Install electrical fittings and fixtures | 2017-02-23 → 2017-03-02 (+7d) | 2017-03-08 → 2017-03-15 (+7d) |  |  |
| 25 | Install all plumbing | 2017-02-16 → 2017-02-23 (+7d) | 2017-03-01 → 2017-03-08 (+7d) |  |  |
| 26 | Install plumbing fittings and fixtures | 2017-03-02 → 2017-03-09 (+7d) | 2017-03-08 → 2017-03-15 (+7d) |  |  |
| 27 | Lay astro turf | 2017-02-16 → 2017-02-23 (+7d) | 2017-02-22 → 2017-03-01 (+7d) |  |  |
| 28 | Erect handrails and fencing | 2017-02-16 → 2017-02-23 (+7d) | 2017-03-01 → 2017-03-08 (+7d) |  |  |
| 29 | Paint rooms, fixtures, fittings, etc | 2017-02-28 → 2017-03-07 (+7d) | 2017-03-27 → 2017-04-03 (+7d) |  |  |
| 30 | Install PA system | 2017-02-23 → 2017-03-02 (+7d) | 2017-02-24 → 2017-03-03 (+7d) |  |  |
| 31 | Install video imaging equipment | 2017-02-23 → 2017-03-02 (+7d) | 2017-02-27 → 2017-03-06 (+7d) |  |  |
| 32 | Fit out control room | 2017-03-28 → 2017-04-04 (+7d) | 2017-04-03 → 2017-04-10 (+7d) |  |  |
| 33 | Fit Out Completed | 2017-04-03 → 2017-04-10 (+7d) | 2017-04-03 → 2017-04-10 (+7d) |  |  |
| 34 | **Commissioning** | 2017-04-04 → 2017-04-11 (+7d) | 2017-04-21 → 2017-04-28 (+7d) |  |  |
| 35 | Test roof mechanism | 2017-04-04 → 2017-04-11 (+7d) | 2017-04-10 → 2017-04-17 (+7d) |  |  |
| 36 | Test PA system | 2017-04-04 → 2017-04-11 (+7d) | 2017-04-05 → 2017-04-12 (+7d) |  |  |
| 37 | Test video imaging equipment | 2017-04-04 → 2017-04-11 (+7d) | 2017-04-05 → 2017-04-12 (+7d) |  |  |
| 38 | Test control room equipment | 2017-04-11 → 2017-04-18 (+7d) | 2017-04-17 → 2017-04-24 (+7d) |  |  |
| 39 | Obtain official occupancy certificates | 2017-04-18 → 2017-04-25 (+7d) | 2017-04-18 → 2017-04-25 (+7d) |  |  |
| 40 | Obtain safety certification | 2017-04-19 → 2017-04-26 (+7d) | 2017-04-20 → 2017-04-27 (+7d) |  |  |
| 41 | Official opening | 2017-04-21 → 2017-04-28 (+7d) | 2017-04-21 → 2017-04-28 (+7d) |  |  |
| 42 | Commissioning Completed | 2017-04-21 → 2017-04-28 (+7d) | 2017-04-21 → 2017-04-28 (+7d) |  |  |

## Version 26 (saved 2013-08-07, file J1310 Materials_2.mpp)

Last finish 2017-04-28 → 2017-05-08 (+10d).

Changed:

| ID | Task | Start | Finish | Duration | Predecessors | Other |
| --- | --- | --- | --- | --- | --- | --- |
| 13 | **Building Construction** |  | 2017-02-22 → 2017-03-02 (+8d) | 125d → 131d |  |  |
| 16 | Erect wall | 2016-11-07 → 2016-11-15 (+8d) | 2017-01-18 → 2017-01-26 (+8d) |  | 15FS-1% → 15 |  |
| 17 | Install roofing superstructure | 2017-01-19 → 2017-01-27 (+8d) | 2017-02-01 → 2017-02-09 (+8d) |  |  |  |
| 18 | Install roofing retracting mechanism | 2017-02-02 → 2017-02-10 (+8d) | 2017-02-08 → 2017-02-16 (+8d) |  |  |  |
| 19 | Erect seating tiers | 2017-02-02 → 2017-02-10 (+8d) | 2017-02-22 → 2017-03-02 (+8d) |  |  |  |
| 20 | Building Construction Completed | 2017-02-22 → 2017-03-02 (+8d) | 2017-02-22 → 2017-03-02 (+8d) |  |  |  |
| 21 | **Fit Out** | 2017-02-23 → 2017-03-03 (+8d) | 2017-04-10 → 2017-04-18 (+8d) |  |  |  |
| 22 | Fit all windows and doors | 2017-02-23 → 2017-03-03 (+8d) | 2017-03-08 → 2017-03-16 (+8d) |  |  |  |
| 23 | Install electrical cabling | 2017-02-23 → 2017-03-03 (+8d) | 2017-03-01 → 2017-03-09 (+8d) |  |  |  |
| 24 | Install electrical fittings and fixtures | 2017-03-02 → 2017-03-10 (+8d) | 2017-03-15 → 2017-03-23 (+8d) |  |  |  |
| 25 | Install all plumbing | 2017-02-23 → 2017-03-03 (+8d) | 2017-03-08 → 2017-03-16 (+8d) |  |  |  |
| 26 | Install plumbing fittings and fixtures | 2017-03-09 → 2017-03-17 (+8d) | 2017-03-15 → 2017-03-23 (+8d) |  |  |  |
| 27 | Lay astro turf | 2017-02-23 → 2017-03-03 (+8d) | 2017-03-01 → 2017-03-09 (+8d) |  |  | resources Pure Grass Turf → Pure Grass Turf; Astro Turf [17850 Square Metre] |
| 28 | Erect handrails and fencing | 2017-02-23 → 2017-03-03 (+8d) | 2017-03-08 → 2017-03-16 (+8d) |  |  |  |
| 29 | Paint rooms, fixtures, fittings, etc | 2017-03-07 → 2017-03-15 (+8d) | 2017-04-03 → 2017-04-11 (+8d) |  |  | resources Painter [500%] → Painter [500%]; Paint [1500 Litre] |
| 30 | Install PA system | 2017-03-02 → 2017-03-10 (+8d) | 2017-03-03 → 2017-03-13 (+10d) |  |  |  |
| 31 | Install video imaging equipment | 2017-03-02 → 2017-03-10 (+8d) | 2017-03-06 → 2017-03-14 (+8d) |  |  |  |
| 32 | Fit out control room | 2017-04-04 → 2017-04-12 (+8d) | 2017-04-10 → 2017-04-18 (+8d) |  |  |  |
| 33 | Fit Out Completed | 2017-04-10 → 2017-04-18 (+8d) | 2017-04-10 → 2017-04-18 (+8d) |  |  |  |
| 34 | **Commissioning** | 2017-04-11 → 2017-04-19 (+8d) | 2017-04-28 → 2017-05-08 (+10d) |  |  |  |
| 35 | Test roof mechanism | 2017-04-11 → 2017-04-19 (+8d) | 2017-04-17 → 2017-04-25 (+8d) |  |  |  |
| 36 | Test PA system | 2017-04-11 → 2017-04-19 (+8d) | 2017-04-12 → 2017-04-20 (+8d) |  |  |  |
| 37 | Test video imaging equipment | 2017-04-11 → 2017-04-19 (+8d) | 2017-04-12 → 2017-04-20 (+8d) |  |  |  |
| 38 | Test control room equipment | 2017-04-18 → 2017-04-26 (+8d) | 2017-04-24 → 2017-05-02 (+8d) |  |  |  |
| 39 | Obtain official occupancy certificates | 2017-04-25 → 2017-05-03 (+8d) | 2017-04-25 → 2017-05-03 (+8d) |  |  |  |
| 40 | Obtain safety certification | 2017-04-26 → 2017-05-04 (+8d) | 2017-04-27 → 2017-05-05 (+8d) |  |  |  |
| 41 | Official opening | 2017-04-28 → 2017-05-08 (+10d) | 2017-04-28 → 2017-05-08 (+10d) |  |  |  |
| 42 | Commissioning Completed | 2017-04-28 → 2017-05-08 (+10d) | 2017-04-28 → 2017-05-08 (+10d) |  |  |  |

## Version 27 (saved 2013-08-07, file J1310 Materials_1.mpp)

Last finish stays 2017-05-08.

Changed:

| ID | Task | Other |
| --- | --- | --- |
| 27 | Lay astro turf | resources Pure Grass Turf; Astro Turf [17850 Square Metre] → Pure Grass Turf |
| 29 | Paint rooms, fixtures, fittings, etc | resources Painter [500%]; Paint [1500 Litre] → Painter [500%] |

## Version 28 (saved 2013-08-07, file J1310 Materials_3.mpp)

Last finish stays 2017-05-08.

Changed:

| ID | Task | Other |
| --- | --- | --- |
| 27 | Lay astro turf | resources Pure Grass Turf → Pure Grass Turf; Astro Turf [17850 Square Metre] |
| 29 | Paint rooms, fixtures, fittings, etc | resources Painter [500%] → Painter [500%]; Paint [1500 Litre] |

## Version 29 (saved 2013-08-07, file J1310 Materials_5.mpp)

Last finish stays 2017-05-08.

Changed:

| ID | Task | Other |
| --- | --- | --- |
| 9 | Clear and level site | resources Driver [200%]; Grader [200%]; Supervisor → Driver [200%]; Grader [200%]; Supervisor; Diesel Fuel [16 Litre] |
| 15 | Erect steelwork | resources Supervisor [50%]; Rigger [500%]; Boilermaker [600%]; Welder [500%]; Labourer [600%]; Driver [200%]; High Jib Crane; Utility → Supervisor [50%]; Rigger [500%]; Boilermaker [600%]; Welder [500%]; Labourer [600%]; Driver [200%]; High Jib Crane; Utility; Diesel Fuel [12 Litre]; Unleaded Petrol [4 litre] |
| 16 | Erect wall | resources Supervisor [50%]; Carpenter [600%]; Labourer [400%]; Driver; Grader; Air Compressor; Electrician [75%]; Plumber [25%]; On The Hammer → Supervisor [50%]; Carpenter [600%]; Labourer [400%]; Driver; Grader; Air Compressor; Electrician [75%]; Plumber [25%]; On The Hammer; Diesel Fuel [8 Litre] |
| 17 | Install roofing superstructure | resources Supervisor [50%]; Rigger [500%]; Boilermaker [500%]; Welder [300%]; Labourer [500%]; Driver [200%]; High Jib Crane; Utility; Air Compressor; Plumber [50%] → Supervisor [50%]; Rigger [500%]; Boilermaker [500%]; Welder [300%]; Labourer [500%]; Driver [200%]; High Jib Crane; Utility; Air Compressor; Plumber [50%]; Diesel Fuel [12 Litre]; Unleaded Petrol [4 litre] |
| 18 | Install roofing retracting mechanism | resources Supervisor [50%]; Welder; Boilermaker [200%]; Rigger [200%]; Electrician [200%]; Driver; High Jib Crane → Supervisor [50%]; Welder; Boilermaker [200%]; Rigger [200%]; Electrician [200%]; Driver; High Jib Crane; Diesel Fuel [12 Litre] |
| 19 | Erect seating tiers | resources Supervisor [50%]; Carpenter [600%]; Welder [200%]; Boilermaker [200%]; Labourer [700%]; Driver; Utility; Air Compressor → Supervisor [50%]; Carpenter [600%]; Welder [200%]; Boilermaker [200%]; Labourer [700%]; Driver; Utility; Air Compressor; Unleaded Petrol [4 litre]; Diesel Fuel [6 Litre] |

## Version 30 (saved 2013-08-07, file J1310 Materials_6.mpp)

Last finish stays 2017-05-08.

Changed:

| ID | Task | Other |
| --- | --- | --- |
| 16 | Erect wall | resources Supervisor [50%]; Carpenter [600%]; Labourer [400%]; Driver; Grader; Air Compressor; Electrician [75%]; Plumber [25%]; On The Hammer; Diesel Fuel [8 Litre] → Supervisor [50%]; Carpenter [600%]; Labourer [400%]; Driver; Grader; Air Compressor; Electrician [75%]; Plumber [25%]; On The Hammer; Diesel Fuel [14 Litre] |
| 17 | Install roofing superstructure | resources Supervisor [50%]; Rigger [500%]; Boilermaker [500%]; Welder [300%]; Labourer [500%]; Driver [200%]; High Jib Crane; Utility; Air Compressor; Plumber [50%]; Diesel Fuel [12 Litre]; Unleaded Petrol [4 litre] → Supervisor [50%]; Rigger [500%]; Boilermaker [500%]; Welder [300%]; Labourer [500%]; Driver [200%]; High Jib Crane; Utility; Air Compressor; Plumber [50%]; Diesel Fuel [18 Litre]; Unleaded Petrol [4 litre] |

## Version 31 (saved 2013-08-08, file J1311 Costs_10.mpp)

Last finish stays 2017-05-08.

Changed:

| ID | Task | Other |
| --- | --- | --- |
| 3 | Submit plans for approval | resources Architect → Architect; Building Permit [0.1%] |
| 41 | Official opening | resources none → End of Project Party [0.1%] |

## Version 32 (saved 2013-08-12, file J1312 Constraints_2.mpp)

Last finish 2017-05-08 → 2017-05-05 (-3d).

Changed:

| ID | Task | Start | Finish | Duration | Total float | Other |
| --- | --- | --- | --- | --- | --- | --- |
| 34 | **Commissioning** |  | 2017-05-08 → 2017-05-05 (-3d) | 14d → 13d | 0d → -5d |  |
| 41 | Official opening | 2017-05-08 → 2017-04-29 (-9d) | 2017-05-08 → 2017-05-01 (-7d) |  | 0d → -5d | constraint none → must start on 2017-04-29 |
| 42 | Commissioning Completed | 2017-05-08 → 2017-05-05 (-3d) | 2017-05-08 → 2017-05-05 (-3d) |  |  |  |

## Version 33 (saved 2013-08-12, file J1312 Constraints_3.mpp)

Last finish stays 2017-05-05.

Changed:

| ID | Task | Finish | Duration | Total float |
| --- | --- | --- | --- | --- |
| 41 | Official opening | 2017-05-01 → 2017-04-29 (-2d) | 1d → 3eh | -5d → -18.67d |

## Version 34 (saved 2013-08-12, file J1312 Constraints_4.mpp)

Last finish 2017-05-05 → 2017-04-29 (-6d).

Changed:

| ID | Task | Start | Finish | Duration | Total float |
| --- | --- | --- | --- | --- | --- |
| 34 | **Commissioning** |  | 2017-05-05 → 2017-04-29 (-6d) | 13d → 8d | -5d → 0d |
| 35 | Test roof mechanism |  | 2017-04-25 → 2017-04-21 (-4d) | 1w → 3d | -5d → 0d |
| 38 | Test control room equipment | 2017-04-26 → 2017-04-24 (-2d) | 2017-05-02 → 2017-04-26 (-6d) | 1w → 3d | -5d → 0d |
| 39 | Obtain official occupancy certificates | 2017-05-03 → 2017-04-27 (-6d) | 2017-05-03 → 2017-04-27 (-6d) |  | -5d → 0d |
| 40 | Obtain safety certification | 2017-05-04 → 2017-04-28 (-6d) | 2017-05-05 → 2017-04-28 (-7d) | 2d → 1d | -5d → 0d |
| 42 | Commissioning Completed | 2017-05-05 → 2017-04-29 (-6d) | 2017-05-05 → 2017-04-29 (-6d) |  |  |

## Version 35 (saved 2013-08-12, file J1313 Tracking_2.mpp)

Last finish stays 2017-04-29.

Changed:

| ID | Task | Other |
| --- | --- | --- |
| 1 | **Planning** | baseline start none → 2016-05-09; baseline finish none → 2016-07-06 |
| 2 | Create architectural plans | baseline start none → 2016-05-09; baseline finish none → 2016-05-27 |
| 3 | Submit plans for approval | baseline start none → 2016-05-30; baseline finish none → 2016-06-24 |
| 4 | Order materials | baseline start none → 2016-06-27; baseline finish none → 2016-07-06 |
| 5 | Planning Completed | baseline start none → 2016-07-06; baseline finish none → 2016-07-06 |
| 6 | **Site Works** | baseline start none → 2016-07-07; baseline finish none → 2016-08-12 |
| 7 | Erect fencing | baseline start none → 2016-07-07; baseline finish none → 2016-07-11 |
| 8 | Erect site buildings | baseline start none → 2016-07-12; baseline finish none → 2016-07-15 |
| 9 | Clear and level site | baseline start none → 2016-07-18; baseline finish none → 2016-08-05 |
| 10 | Prepare drainage infrastructure | baseline start none → 2016-08-08; baseline finish none → 2016-08-12 |
| 11 | Prepare cabling infrastructure | baseline start none → 2016-08-08; baseline finish none → 2016-08-12 |
| 12 | Site Works Completed | baseline start none → 2016-08-12; baseline finish none → 2016-08-12 |
| 13 | **Building Construction** | baseline start none → 2016-08-15; baseline finish none → 2017-03-02 |
| 14 | Pour foundations | baseline start none → 2016-08-15; baseline finish none → 2016-08-18 |
| 15 | Erect steelwork | baseline start none → 2016-08-23; baseline finish none → 2016-11-14 |
| 16 | Erect wall | baseline start none → 2016-11-15; baseline finish none → 2017-01-26 |
| 17 | Install roofing superstructure | baseline start none → 2017-01-27; baseline finish none → 2017-02-09 |
| 18 | Install roofing retracting mechanism | baseline start none → 2017-02-10; baseline finish none → 2017-02-16 |
| 19 | Erect seating tiers | baseline start none → 2017-02-10; baseline finish none → 2017-03-02 |
| 20 | Building Construction Completed | baseline start none → 2017-03-02; baseline finish none → 2017-03-02 |
| 21 | **Fit Out** | baseline start none → 2017-03-03; baseline finish none → 2017-04-18 |
| 22 | Fit all windows and doors | baseline start none → 2017-03-03; baseline finish none → 2017-03-16 |
| 23 | Install electrical cabling | baseline start none → 2017-03-03; baseline finish none → 2017-03-09 |
| 24 | Install electrical fittings and fixtures | baseline start none → 2017-03-10; baseline finish none → 2017-03-23 |
| 25 | Install all plumbing | baseline start none → 2017-03-03; baseline finish none → 2017-03-16 |
| 26 | Install plumbing fittings and fixtures | baseline start none → 2017-03-17; baseline finish none → 2017-03-23 |
| 27 | Lay astro turf | baseline start none → 2017-03-03; baseline finish none → 2017-03-09 |
| 28 | Erect handrails and fencing | baseline start none → 2017-03-03; baseline finish none → 2017-03-16 |
| 29 | Paint rooms, fixtures, fittings, etc | baseline start none → 2017-03-15; baseline finish none → 2017-04-11 |
| 30 | Install PA system | baseline start none → 2017-03-10; baseline finish none → 2017-03-13 |
| 31 | Install video imaging equipment | baseline start none → 2017-03-10; baseline finish none → 2017-03-14 |
| 32 | Fit out control room | baseline start none → 2017-04-12; baseline finish none → 2017-04-18 |
| 33 | Fit Out Completed | baseline start none → 2017-04-18; baseline finish none → 2017-04-18 |
| 34 | **Commissioning** | baseline start none → 2017-04-19; baseline finish none → 2017-04-29 |
| 35 | Test roof mechanism | baseline start none → 2017-04-19; baseline finish none → 2017-04-21 |
| 36 | Test PA system | baseline start none → 2017-04-19; baseline finish none → 2017-04-20 |
| 37 | Test video imaging equipment | baseline start none → 2017-04-19; baseline finish none → 2017-04-20 |
| 38 | Test control room equipment | baseline start none → 2017-04-24; baseline finish none → 2017-04-26 |
| 39 | Obtain official occupancy certificates | baseline start none → 2017-04-27; baseline finish none → 2017-04-27 |
| 40 | Obtain safety certification | baseline start none → 2017-04-28; baseline finish none → 2017-04-28 |
| 41 | Official opening | baseline start none → 2017-04-29; baseline finish none → 2017-04-29 |
| 42 | Commissioning Completed | baseline start none → 2017-04-29; baseline finish none → 2017-04-29 |

## Version 36 (saved 2013-08-12, file J1313 Tracking_3.mpp)

Last finish stays 2017-04-29. Complete tasks 0 → 2.

Changed:

| ID | Task | Start | Finish | Complete | Total float |
| --- | --- | --- | --- | --- | --- |
| 1 | **Planning** | 2016-05-09 A |  | 0% → 89% |  |
| 2 | Create architectural plans | 2016-05-09 A | 2016-05-27 A | 0% → 100% | 0d → none |
| 3 | Submit plans for approval | 2016-05-30 A | 2016-06-24 A | 0% → 100% | 0d → none |
| 4 | Order materials | 2016-06-27 A |  | 0% → 38% |  |

## Version 37 (saved 2013-08-12, file J1313 Tracking_4.mpp)

Last finish stays 2017-04-29. Complete tasks 2 → 13.

Changed:

| ID | Task | Start | Finish | Complete | Total float |
| --- | --- | --- | --- | --- | --- |
| 1 | **Planning** |  | 2016-07-06 A | 89% → 100% | 0d → none |
| 4 | Order materials |  | 2016-07-06 A | 38% → 100% | 0d → none |
| 5 | Planning Completed | 2016-07-06 A | 2016-07-06 A | 0% → 100% | 0d → none |
| 6 | **Site Works** | 2016-07-07 A | 2016-08-12 A | 0% → 100% | 0d → none |
| 7 | Erect fencing | 2016-07-07 A | 2016-07-11 A | 0% → 100% | 0d → none |
| 8 | Erect site buildings | 2016-07-12 A | 2016-07-15 A | 0% → 100% | 0d → none |
| 9 | Clear and level site | 2016-07-18 A | 2016-08-05 A | 0% → 100% | 0d → none |
| 10 | Prepare drainage infrastructure | 2016-08-08 A | 2016-08-12 A | 0% → 100% | 0d → none |
| 11 | Prepare cabling infrastructure | 2016-08-08 A | 2016-08-12 A | 0% → 100% | 0d → none |
| 12 | Site Works Completed | 2016-08-12 A | 2016-08-12 A | 0% → 100% | 0d → none |
| 13 | **Building Construction** | 2016-08-15 A |  | 0% → 78% |  |
| 14 | Pour foundations | 2016-08-15 A | 2016-08-18 A | 0% → 100% | 0d → none |
| 15 | Erect steelwork | 2016-08-23 A | 2016-11-14 A | 0% → 100% | 0d → none |
| 16 | Erect wall | 2016-11-15 A | 2017-01-26 A | 0% → 100% | 0d → none |

## Version 38 (saved 2013-08-12, file J1313 Tracking_5.mpp)

Last finish 2017-04-29 → 2017-05-03 (+4d). Complete tasks 13 → 14.

Changed:

| ID | Task | Start | Finish | Duration | Complete | Total float |
| --- | --- | --- | --- | --- | --- | --- |
| 13 | **Building Construction** |  | 2017-03-02 → 2017-03-07 (+5d) | 131d → 134d | 78% → 85% | 0d → -3d |
| 17 | Install roofing superstructure | 2017-01-27 → 2017-02-01 A (+5d) | 2017-02-09 → 2017-02-14 A (+5d) |  | 0% → 100% | 0d → none |
| 18 | Install roofing retracting mechanism | 2017-02-10 → 2017-02-15 (+5d) | 2017-02-16 → 2017-02-21 (+5d) |  |  | 0d → -3d |
| 19 | Erect seating tiers | 2017-02-10 → 2017-02-15 (+5d) | 2017-03-02 → 2017-03-07 (+5d) |  |  | 0d → -3d |
| 20 | Building Construction Completed | 2017-03-02 → 2017-03-07 (+5d) | 2017-03-02 → 2017-03-07 (+5d) |  |  | 0d → -3d |
| 21 | **Fit Out** | 2017-03-03 → 2017-03-08 (+5d) | 2017-04-18 → 2017-04-21 (+3d) |  |  | 0d → -3d |
| 22 | Fit all windows and doors | 2017-03-03 → 2017-03-08 (+5d) | 2017-03-16 → 2017-03-21 (+5d) |  |  | 23d → 20d |
| 23 | Install electrical cabling | 2017-03-03 → 2017-03-08 (+5d) | 2017-03-09 → 2017-03-14 (+5d) |  |  | 18d → 15d |
| 24 | Install electrical fittings and fixtures | 2017-03-10 → 2017-03-15 (+5d) | 2017-03-23 → 2017-03-28 (+5d) |  |  | 18d → 15d |
| 25 | Install all plumbing | 2017-03-03 → 2017-03-08 (+5d) | 2017-03-16 → 2017-03-21 (+5d) |  |  | 18d → 15d |
| 26 | Install plumbing fittings and fixtures | 2017-03-17 → 2017-03-22 (+5d) | 2017-03-23 → 2017-03-28 (+5d) |  |  | 18d → 15d |
| 27 | Lay astro turf | 2017-03-03 → 2017-03-08 (+5d) | 2017-03-09 → 2017-03-14 (+5d) |  |  | 28d → 25d |
| 28 | Erect handrails and fencing | 2017-03-03 → 2017-03-08 (+5d) | 2017-03-16 → 2017-03-21 (+5d) |  |  | 0d → -3d |
| 29 | Paint rooms, fixtures, fittings, etc | 2017-03-15 → 2017-03-20 (+5d) | 2017-04-11 → 2017-04-14 (+3d) |  |  | 0d → -3d |
| 30 | Install PA system | 2017-03-10 → 2017-03-15 (+5d) | 2017-03-13 → 2017-03-16 (+3d) |  |  | 21d → 18d |
| 31 | Install video imaging equipment | 2017-03-10 → 2017-03-15 (+5d) | 2017-03-14 → 2017-03-17 (+3d) |  |  | 20d → 17d |
| 32 | Fit out control room | 2017-04-12 → 2017-04-17 (+5d) | 2017-04-18 → 2017-04-21 (+3d) |  |  | 0d → -3d |
| 33 | Fit Out Completed | 2017-04-18 → 2017-04-21 (+3d) | 2017-04-18 → 2017-04-21 (+3d) |  |  | 0d → -3d |
| 34 | **Commissioning** | 2017-04-19 → 2017-04-24 (+5d) | 2017-04-29 → 2017-05-03 (+4d) |  |  | 0d → -3d |
| 35 | Test roof mechanism | 2017-04-19 → 2017-04-24 (+5d) | 2017-04-21 → 2017-04-26 (+5d) |  |  | 0d → -3d |
| 36 | Test PA system | 2017-04-19 → 2017-04-24 (+5d) | 2017-04-20 → 2017-04-25 (+5d) |  |  | 1d → -2d |
| 37 | Test video imaging equipment | 2017-04-19 → 2017-04-24 (+5d) | 2017-04-20 → 2017-04-25 (+5d) |  |  | 1d → -2d |
| 38 | Test control room equipment | 2017-04-24 → 2017-04-27 (+3d) | 2017-04-26 → 2017-05-01 (+5d) |  |  | 0d → -3d |
| 39 | Obtain official occupancy certificates | 2017-04-27 → 2017-05-02 (+5d) | 2017-04-27 → 2017-05-02 (+5d) |  |  | 0d → -3d |
| 40 | Obtain safety certification | 2017-04-28 → 2017-05-03 (+5d) | 2017-04-28 → 2017-05-03 (+5d) |  |  | 0d → -3d |
| 42 | Commissioning Completed | 2017-04-29 → 2017-05-03 (+4d) | 2017-04-29 → 2017-05-03 (+4d) |  |  |  |

## Version 39 (saved 2013-08-12, file J1313 Tracking_6.mpp)

Last finish stays 2017-05-03. Complete tasks 14 → 15.

Changed:

| ID | Task | Start | Finish | Complete | Total float |
| --- | --- | --- | --- | --- | --- |
| 13 | **Building Construction** |  |  | 85% → 97% | -3d → 0d |
| 18 | Install roofing retracting mechanism | 2017-02-15 A | 2017-02-21 A | 0% → 100% | -3d → none |
| 19 | Erect seating tiers | 2017-02-15 A |  | 0% → 75% |  |

## Version 40 (saved 2013-08-13, file J1313 Tracking_7.mpp)

Last finish 2017-05-03 → 2017-05-01 (-2d). Complete tasks 15 → 16.

Changed:

| ID | Task | Start | Finish | Duration | Complete | Total float |
| --- | --- | --- | --- | --- | --- | --- |
| 13 | **Building Construction** |  | 2017-03-07 → 2017-03-03 (-4d) | 134d → 132d | 97% → 99% |  |
| 19 | Erect seating tiers |  | 2017-03-07 → 2017-03-03 A (-4d) | 3w → 2.6w | 75% → 100% | -3d → none |
| 20 | Building Construction Completed | 2017-03-07 → 2017-03-03 (-4d) | 2017-03-07 → 2017-03-03 (-4d) |  |  | -3d → -1d |
| 21 | **Fit Out** | 2017-03-08 → 2017-03-06 (-2d) | 2017-04-21 → 2017-04-19 (-2d) |  |  | -3d → -1d |
| 22 | Fit all windows and doors | 2017-03-08 → 2017-03-06 (-2d) | 2017-03-21 → 2017-03-17 (-4d) |  |  | 20d → 22d |
| 23 | Install electrical cabling | 2017-03-08 → 2017-03-06 (-2d) | 2017-03-14 → 2017-03-10 (-4d) |  |  | 15d → 17d |
| 24 | Install electrical fittings and fixtures | 2017-03-15 → 2017-03-13 (-2d) | 2017-03-28 → 2017-03-24 (-4d) |  |  | 15d → 17d |
| 25 | Install all plumbing | 2017-03-08 → 2017-03-06 (-2d) | 2017-03-21 → 2017-03-17 (-4d) |  |  | 15d → 17d |
| 26 | Install plumbing fittings and fixtures | 2017-03-22 → 2017-03-20 (-2d) | 2017-03-28 → 2017-03-24 (-4d) |  |  | 15d → 17d |
| 27 | Lay astro turf | 2017-03-08 → 2017-03-06 (-2d) | 2017-03-14 → 2017-03-10 (-4d) |  |  | 25d → 27d |
| 28 | Erect handrails and fencing | 2017-03-08 → 2017-03-06 (-2d) | 2017-03-21 → 2017-03-17 (-4d) |  |  | -3d → -1d |
| 29 | Paint rooms, fixtures, fittings, etc | 2017-03-20 → 2017-03-16 (-4d) | 2017-04-14 → 2017-04-12 (-2d) |  |  | -3d → -1d |
| 30 | Install PA system | 2017-03-15 → 2017-03-13 (-2d) | 2017-03-16 → 2017-03-14 (-2d) |  |  | 18d → 20d |
| 31 | Install video imaging equipment | 2017-03-15 → 2017-03-13 (-2d) | 2017-03-17 → 2017-03-15 (-2d) |  |  | 17d → 19d |
| 32 | Fit out control room | 2017-04-17 → 2017-04-13 (-4d) | 2017-04-21 → 2017-04-19 (-2d) |  |  | -3d → -1d |
| 33 | Fit Out Completed | 2017-04-21 → 2017-04-19 (-2d) | 2017-04-21 → 2017-04-19 (-2d) |  |  | -3d → -1d |
| 34 | **Commissioning** | 2017-04-24 → 2017-04-20 (-4d) | 2017-05-03 → 2017-05-01 (-2d) |  |  | -3d → -1d |
| 35 | Test roof mechanism | 2017-04-24 → 2017-04-20 (-4d) | 2017-04-26 → 2017-04-24 (-2d) |  |  | -3d → -1d |
| 36 | Test PA system | 2017-04-24 → 2017-04-20 (-4d) | 2017-04-25 → 2017-04-21 (-4d) |  |  | -2d → 0d |
| 37 | Test video imaging equipment | 2017-04-24 → 2017-04-20 (-4d) | 2017-04-25 → 2017-04-21 (-4d) |  |  | -2d → 0d |
| 38 | Test control room equipment | 2017-04-27 → 2017-04-25 (-2d) | 2017-05-01 → 2017-04-27 (-4d) |  |  | -3d → -1d |
| 39 | Obtain official occupancy certificates | 2017-05-02 → 2017-04-28 (-4d) | 2017-05-02 → 2017-04-28 (-4d) |  |  | -3d → -1d |
| 40 | Obtain safety certification | 2017-05-03 → 2017-05-01 (-2d) | 2017-05-03 → 2017-05-01 (-2d) |  |  | -3d → -1d |
| 42 | Commissioning Completed | 2017-05-03 → 2017-05-01 (-2d) | 2017-05-03 → 2017-05-01 (-2d) |  |  |  |
